# ReportResourcesPractice

Schedule from MS Project, 2019-01-07 to 2019-02-04, status date 2019-01-12, costs in $.

## Calendars

- Standard: Mon-Fri 08:00-12:00, 13:00-17:00; Sat-Sun off.
- 7Day: Mon-Sun 08:00-12:00, 13:00-17:00.

## Resources

| Resource | Group | Unit | Rate | Cost per use |
| --- | --- | --- | --- | --- |
| Manager | Internal |  | 48.08 |  |
| Manager's PA | Internal |  | 72.12 |  |
| Techies | Internal |  | 100 |  |
| Moving Company | Contractors |  |  | 5000 |
| Decorators | Contractors |  |  | 5000 |
| Boxes | Consumables | Each | 5 |  |

## Schedule

| ID | WBS | Task | Type | Duration | Start | Finish | Predecessors | Baseline start | Baseline finish | Baseline duration | Total slack | Calendar | Resources | Work | Cost | Baseline cost |
| --- | --- | --- | --- | --- | --- | --- | --- | --- | --- | --- | --- | --- | --- | --- | --- | --- |
| 1 | 1 | **Pre-work** |  | 3.5d | 2019-01-07 | 2019-01-10 |  | 2003-01-06 | 2003-01-09 | 3.62d | 0d |  |  | 24h | 1,682.69 | 1,730.77 |
| 2 | 1.1 | Get Fit-out quotes |  | 2d | 2019-01-07 | 2019-01-08 |  | 2003-01-06 | 2003-01-07 | 2d | 0d |  | Manager's PA | 16h | 1,153.85 | 1,153.85 |
| 3 | 1.2 | Get Moving Company Quotes |  | 1d | 2019-01-09 | 2019-01-09 | 2FS-5% | 2003-01-08 | 2003-01-08 | 1d | 0d |  | Manager's PA [50%] | 4h | 288.46 | 288.46 |
| 4 | 1.3 | Evaluate and Accept Quotes |  | 2h | 2019-01-10 | 2019-01-10 | 3 | 2003-01-09 | 2003-01-09 | 3h | 0d |  | Manager | 2h | 96.15 | 144.23 |
| 5 | 1.4 | Confirm Moving Day |  | 2h | 2019-01-10 | 2019-01-10 | 4 | 2003-01-09 | 2003-01-09 | 2h | 0d |  | Manager's PA | 2h | 144.23 | 144.23 |
| 6 | 2 | **Fit Out New Premises** |  | 6.5d | 2019-01-10 | 2019-01-18 | 1 | 2003-01-09 | 2003-01-21 | 7.5d | 0d |  |  | 144h | 15,600 | 16,298.08 |
| 7 | 2.1 | Power |  | 0.5d | 2019-01-10 | 2019-01-10 |  | 2003-01-09 | 2003-01-10 | 0.5d | 0d |  | Techies | 4h | 400 | 400 |
| 8 | 2.2 | Cabling |  | 4d | 2019-01-11 | 2019-01-14 | 7 | 2003-01-10 | 2003-01-16 | 4d | 0d | 7Day | Techies [300%] | 100h | 10,200 | 10,176.92 |
| 9 | 2.3 | Decorating |  | 1w | 2019-01-14 | 2019-01-18 | 8FS-1d | 2003-01-14 | 2003-01-21 | 1w | 0d |  | Decorators | 40h | 5,000 | 5,721.15 |
| 10 | 3 | **Packing** |  | 5d | 2019-01-21 | 2019-01-27 | 6 | 2003-01-21 | 2003-01-30 | 6d | 0d |  |  | 192h | 18,184.62 | 19,134.62 |
| 11 | 3.1 | Get Boxes |  | 2d | 2019-01-21 | 2019-01-22 |  | 2003-01-21 | 2003-01-22 | 1d | 0d |  | Boxes [20 Each]; Techies [200%] | 32h | 3,300 | 1,700 |
| 12 | 3.2 | Pack boxes |  | 1w | 2019-01-23 | 2019-01-27 | 11 | 2003-01-22 | 2003-01-30 | 1w | 0d | 7Day | Techies [300%] | 120h | 12,000 | 14,550 |
| 13 | 3.3 | Make Inventory |  | 1w | 2019-01-23 | 2019-01-27 | 12SS | 2003-01-22 | 2003-01-30 | 1w | 0d | 7Day | Manager's PA | 40h | 2,884.62 | 2,884.62 |
| 14 | 4 | Transport Boxes |  | 1d | 2019-01-28 | 2019-01-28 | 10 | 2003-01-30 | 2003-01-31 | 1ed | 0d |  | Moving Company | 8h | 5,000 | 5,000 |
| 15 | 5 | **Unpacking** |  | 5d | 2019-01-29 | 2019-02-04 | 14 | 2003-01-31 | 2003-02-10 | 5d | 0d |  |  | 160h | 14,884.62 | 20,884.62 |
| 16 | 5.1 | Unpack Boxes |  | 1w | 2019-01-29 | 2019-02-04 |  | 2003-01-31 | 2003-02-10 | 1w | 0d |  | Techies [150%] | 60h | 6,000 | 9,000 |
| 17 | 5.2 | Install Equipment |  | 1w | 2019-01-29 | 2019-02-04 | 16FF | 2003-01-31 | 2003-02-10 | 1w | 0d |  | Techies [150%] | 60h | 6,000 | 9,000 |
| 18 | 5.3 | Check Inventory |  | 1w | 2019-01-29 | 2019-02-04 | 17FF | 2003-01-31 | 2003-02-10 | 1w | 0d |  | Manager's PA | 40h | 2,884.62 | 2,884.62 |
| 19 | 6 | Move In | milestone | 0d | 2019-02-04 | 2019-02-04 | 15 | 2003-02-10 | 2003-02-10 | 0d | 0d |  |  |  |  |  |
