# Reporting16

Schedule from MS Project, 2019-01-07 to 2019-04-05, status date 2019-03-12, 7.5 hours a day, costs in $, A marks actual dates.

## Calendars

- Standard: Mon-Fri 09:00-12:00, 12:30-17:00; Sat-Sun off.

## Schedule

| ID | WBS | Task | Type | Duration | Start | Finish | Predecessors | Complete | Remaining | Baseline start | Baseline finish | Baseline duration | Total slack | Constraint | Deadline | Cost | Baseline cost | Actual cost |
| --- | --- | --- | --- | --- | --- | --- | --- | --- | --- | --- | --- | --- | --- | --- | --- | --- | --- | --- |
| 1 | 1 | **Phase 1** |  | 35d | 2019-01-07 A | 2019-02-24 A |  | 100% |  | 2019-01-07 | 2019-02-18 | 31d |  |  |  | 11,100 | 11,100 | 11,100 |
| 2 | 1.1 | Plan Submission |  | 10d | 2019-01-07 A | 2019-01-18 A |  | 100% |  | 2019-01-07 | 2019-01-18 | 10d |  |  |  |  |  |  |
| 3 | 1.2 | Write Submission |  | 2.8w | 2019-01-21 A | 2019-02-07 A | 2 | 100% |  | 2019-01-21 | 2019-02-01 | 2w |  | finish no later than 2019-02-06 | 2019-02-06 | 1,000 | 1,000 | 1,000 |
| 4 | 1.3 | Mail to London |  | 3ed | 2019-02-07 A | 2019-02-10 A | 3 | 100% |  | 2019-02-01 | 2019-02-04 | 3ed |  |  |  | 100 | 100 | 100 |
| 5 | 1.4 | EU Meetings |  | 2ew | 2019-02-10 A | 2019-02-24 A | 4 | 100% |  | 2019-02-04 | 2019-02-18 | 2ew |  |  |  | 10,000 | 10,000 | 10,000 |
| 6 | 1.5 | Phase 1 Complete | milestone | 0d | 2019-02-24 A | 2019-02-24 A | 5 | 100% |  | 2019-02-18 | 2019-02-18 | 0d |  |  |  |  |  |  |
| 7 | 2 | **Phase 2** |  | 29d | 2019-02-25 A | 2019-04-05 | 1 | 20% | 23.25d | 2019-02-19 | 2019-04-05 | 33d | 0d |  |  | 11,000 | 11,000 | 750 |
| 8 | 2.1 | Receive Questions |  | 1w | 2019-02-25 A | 2019-03-01 A |  | 100% |  | 2019-02-19 | 2019-02-25 | 1w |  |  |  |  |  |  |
| 9 | 2.2 | Write Answers |  | 2w | 2019-02-27 A | 2019-03-13 | 8FS-5% | 75% | 0.5w | 2019-02-21 | 2019-03-07 | 2w | 5.5d |  |  | 1,000 | 1,000 | 750 |
| 10 | 2.3 | Followup Meetings |  | 15ed | 2019-03-21 | 2019-04-05 | 9 |  |  | 2019-03-21 | 2019-04-05 | 15ed | 0d | must start on 2019-03-21 |  | 10,000 | 10,000 |  |
| 11 | 2.4 | Phase 2 Complete | milestone | 0d | 2019-04-05 | 2019-04-05 | 10 |  |  | 2019-04-05 | 2019-04-05 | 0d | 0d |  |  |  |  |  |
